| id | name | startDate | endDate | priority | barScale | progress | type | parentId | dependencies |
| --- | --- | --- | --- | --- | --- | --- | --- | --- | --- |
| 1 | Home Renovation | 2026-06-01T00:00:00.000Z | 2026-09-21T00:00:00.000Z | medium | 1 | 0 | group |  |  |
| 2 | Scope and finish selects | 2026-06-01T00:00:00.000Z | 2026-06-15T00:00:00.000Z | high | 1 | 0 | task | 1 |  |
| 3 | Architectural drawings | 2026-06-08T00:00:00.000Z | 2026-06-22T00:00:00.000Z | medium | 1 | 0 | task | 1 | 2 SS |
| 4 | Submit for permit | 2026-06-22T00:00:00.000Z | 2026-06-23T00:00:00.000Z | medium | 1 | 0 | milestone | 1 | 3 FS |
| 5 | Permit review | 2026-06-22T00:00:00.000Z | 2026-07-13T00:00:00.000Z | medium | 1 | 0 | task | 1 | 4 FS |
| 6 | Order long-lead materials | 2026-06-15T00:00:00.000Z | 2026-06-22T00:00:00.000Z | high | 1 | 0 | task | 1 |  |
| 7 | Demolition | 2026-06-29T00:00:00.000Z | 2026-07-04T00:00:00.000Z | medium | 1 | 0 | task | 1 | 5 FS |
| 8 | Framing changes | 2026-07-04T00:00:00.000Z | 2026-07-11T00:00:00.000Z | medium | 1 | 0 | task | 1 | 7 FS |
| 9 | Plumbing rough-in | 2026-07-11T00:00:00.000Z | 2026-07-16T00:00:00.000Z | medium | 1 | 0 | task | 1 | 8 FS |
| 10 | Electrical rough-in | 2026-07-13T00:00:00.000Z | 2026-07-18T00:00:00.000Z | medium | 1 | 0 | task | 1 | 8 FS |
| 11 | HVAC rough-in | 2026-07-15T00:00:00.000Z | 2026-07-19T00:00:00.000Z | medium | 1 | 0 | task | 1 | 8 FS |
| 12 | Rough inspections | 2026-07-21T00:00:00.000Z | 2026-07-23T00:00:00.000Z | medium | 1 | 0 | milestone | 1 |  |
| 13 | Drywall | 2026-07-23T00:00:00.000Z | 2026-08-02T00:00:00.000Z | medium | 1 | 0 | task | 1 | 12 FS |
| 14 | Paint | 2026-08-02T00:00:00.000Z | 2026-08-09T00:00:00.000Z | medium | 1 | 0 | task | 1 | 13 FS |
| 15 | Flooring | 2026-08-09T00:00:00.000Z | 2026-08-16T00:00:00.000Z | medium | 1 | 0 | task | 1 | 14 FS |
| 16 | Cabinet install | 2026-08-16T00:00:00.000Z | 2026-08-21T00:00:00.000Z | medium | 1 | 0 | task | 1 | 15 FS |
| 17 | Countertop template | 2026-08-21T00:00:00.000Z | 2026-08-22T00:00:00.000Z | medium | 1 | 0 | milestone | 1 | 16 FS |
| 18 | Countertop install | 2026-08-31T00:00:00.000Z | 2026-09-02T00:00:00.000Z | medium | 1 | 0 | task | 1 | 17 FS |
| 19 | Plumbing and lighting | 2026-09-02T00:00:00.000Z | 2026-09-09T00:00:00.000Z | medium | 1 | 0 | task | 1 |  |
| 20 | Punch list and final | 2026-09-09T00:00:00.000Z | 2026-09-21T00:00:00.000Z | medium | 1 | 0 | task | 1 |  |
